# 118,000 SF Tilt-Wall Distribution Warehouse

How a schedule from Primavera P6 changed from version to version. A marks actual dates.

## Version 1 (data date 2026-07-20, saved 2026-07-17, file sample-commercial.xer)

| ID | WBS | Task | Duration | Start | Finish | Predecessors | Total float |
| --- | --- | --- | --- | --- | --- | --- | --- |
|  | WDH-001.MIL | **Milestones** |  | 2026-07-20 | 2027-06-03 |  |  |
| MIL-00010 |  | Notice to Proceed (NTP) | 0d | 2026-07-20 | 2026-07-20 |  | 0d |
| MIL-00060 |  | Long-Lead POs Issued | 0d | 2026-07-22 | 2026-07-22 | PRO-00010, PRO-00040, PRO-00070 | 27d |
| MIL-00070 |  | All Long-Lead Equipment On Site | 0d | 2026-12-15 | 2026-12-15 | PRO-00030, PRO-00060, PRO-00090 | 92d |
| MIL-00020 |  | Mechanical Completion | 0d | 2027-04-28 | 2027-04-28 | MIL-00070, CON-00130, CON-00150, CON-00160, CON-00200, CON-00220 | 0d |
| MIL-00030 |  | Substantial Completion | 0d | 2027-05-12 | 2027-05-12 | COM-00020, COM-00010 | 0d |
| MIL-00040 |  | Ready for Service | 0d | 2027-05-19 | 2027-05-19 | COM-00030 | 0d |
| CLS-00010 |  | Project Closeout | 10d | 2027-05-20 | 2027-06-03 | MIL-00040 | 0d |
| MIL-00050 |  | Final Completion | 0d | 2027-06-03 | 2027-06-03 | CLS-00010 | 0d |
|  | WDH-001.PRO | **Procurement** |  | 2026-07-20 | 2026-12-15 |  |  |
| PRO-00010 |  | Issue PO — Structural Steel Joists & Deck | 3d | 2026-07-20 | 2026-07-22 | MIL-00010 | 27d |
| PRO-00040 |  | Issue PO — Dock Equipment | 3d | 2026-07-20 | 2026-07-22 | MIL-00010 | 27d |
| PRO-00070 |  | Issue PO — Main Electrical Switchgear | 3d | 2026-07-20 | 2026-07-22 | MIL-00010 | 27d |
| PRO-00020 |  | Fabricate & Deliver Structural Steel Joists & Deck | 75d | 2026-07-23 | 2026-11-06 | MIL-00060 | 27d |
| PRO-00050 |  | Fabricate & Deliver Dock Equipment | 60d | 2026-07-23 | 2026-10-16 | MIL-00060 | 122d |
| PRO-00080 |  | Fabricate & Deliver Main Electrical Switchgear | 100d | 2026-07-23 | 2026-12-15 | MIL-00060 | 87d |
| PRO-00060 |  | Dock Equipment On Site | 0d | 2026-10-16 | 2026-10-16 | PRO-00050 | 122d |
| PRO-00030 |  | Structural Steel Joists & Deck On Site | 0d | 2026-11-06 | 2026-11-06 | PRO-00020 | 27d |
| PRO-00090 |  | Main Electrical Switchgear On Site | 0d | 2026-12-15 | 2026-12-15 | PRO-00080 | 87d |
|  | WDH-001.CON | **Construction** |  | 2026-07-20 | 2027-04-28 |  |  |
|  | WDH-001.CON.01 | **Site & Civil** |  | 2026-07-20 | 2026-08-28 |  |  |
| CON-00010 |  | Perform Mass Grading & Building Pad | 25d | 2026-07-20 | 2026-08-21 | MIL-00010 | 0d |
| CON-00020 |  | Install Site Utilities — Storm & Sanitary | 20d | 2026-08-03 | 2026-08-28 | CON-00010 SS+10d | 140d |
| CON-00030 |  | Install Site Utilities — Water & Fire Loop | 15d | 2026-08-03 | 2026-08-21 | CON-00010 SS+10d | 145d |
|  | WDH-001.CON.02 | **Concrete & Tilt-Wall** |  | 2026-08-24 | 2026-11-25 |  |  |
| CON-00040 |  | Excavate & Form Spread Footings | 15d | 2026-08-24 | 2026-09-14 | CON-00010 | 0d |
| CON-00050 |  | Place Concrete Spread Footings | 10d | 2026-09-15 | 2026-09-28 | CON-00040 | 0d |
| CON-00060 |  | Pour Warehouse Floor Slab — Sections 1 & 2 (Casting Bed) | 10d | 2026-09-29 | 2026-10-13 | CON-00050 | 0d |
| CON-00070 |  | Pour Warehouse Floor Slab — Sections 3 & 4 | 10d | 2026-10-14 | 2026-10-27 | CON-00060 | 70d |
| CON-00080 |  | Cast Tilt-Wall Panels (64 Panels) | 20d | 2026-10-14 | 2026-11-10 | CON-00060 | 0d |
| CON-00090 |  | Cure Tilt-Wall Panels | 10d | 2026-11-12 | 2026-11-25 | CON-00080 | 0d |
|  | WDH-001.CON.03 | **Structure & Envelope** |  | 2026-11-27 | 2027-02-09 |  |  |
| CON-00100 |  | Erect Tilt-Wall Panels with Mobile Crane | 15d | 2026-11-27 | 2026-12-17 | CON-00090 | 0d |
| CON-00110 |  | Erect Structural Steel Joists & Roof Deck | 15d | 2026-12-18 | 2027-01-11 | CON-00100, PRO-00030 | 0d |
| CON-00120 |  | Install TPO Roofing & Insulation | 20d | 2027-01-12 | 2027-02-09 | CON-00110 | 0d |
|  | WDH-001.CON.04 | **Warehouse Interior** |  | 2027-02-10 | 2027-03-24 |  |  |
| CON-00130 |  | Install ESFR Fire Sprinkler System | 25d | 2027-02-10 | 2027-03-17 | CON-00120 | 30d |
| CON-00140 |  | Install Warehouse Electrical & Lighting | 25d | 2027-02-10 | 2027-03-17 | CON-00120 | 25d |
| CON-00160 |  | Install Dock Equipment & Overhead Doors | 10d | 2027-02-10 | 2027-02-24 | PRO-00060, CON-00120 | 45d |
| CON-00150 |  | Set & Energize Main Electrical Switchgear | 5d | 2027-03-18 | 2027-03-24 | CON-00140, PRO-00090 | 25d |
|  | WDH-001.CON.05 | **Office Buildout** |  | 2027-02-10 | 2027-04-28 |  |  |
| CON-00170 |  | Frame Metal Stud Walls — Office | 10d | 2027-02-10 | 2027-02-24 | CON-00120, CON-00070 | 0d |
| CON-00180 |  | Rough-In MEP — Office | 15d | 2027-02-25 | 2027-03-17 | CON-00170 | 0d |
| CON-00190 |  | Install Drywall, Ceilings & Insulation — Office | 15d | 2027-03-18 | 2027-04-07 | CON-00180 | 0d |
| CON-00200 |  | Install Finishes & Storefront Glazing — Office | 15d | 2027-04-08 | 2027-04-28 | CON-00190 | 0d |
|  | WDH-001.CON.06 | **Site Completion** |  | 2026-12-18 | 2027-01-26 |  |  |
| CON-00210 |  | Pave Car Court & Truck Court | 15d | 2026-12-18 | 2027-01-11 | CON-00100, CON-00020, CON-00030 | 65d |
| CON-00220 |  | Install Landscaping & Irrigation | 10d | 2027-01-12 | 2027-01-26 | CON-00210 | 65d |
|  | WDH-001.COM | **Commissioning & Closeout** |  | 2027-04-29 | 2027-05-19 |  |  |
| COM-00010 |  | Perform Commissioning & Start-Up | 10d | 2027-04-29 | 2027-05-12 | CON-00130, CON-00150, CON-00160, CON-00200, CON-00220, MIL-00020 | 0d |
| COM-00020 |  | Complete Punchlist & Final Inspections | 10d | 2027-04-29 | 2027-05-12 | MIL-00020 | 0d |
| COM-00030 |  | Execute Project Closeout | 5d | 2027-05-13 | 2027-05-19 | MIL-00030 | 0d |

## Version 2 (data date 2026-12-01, saved 2026-07-17, file sample-commercial-progressed.xer)

Last finish 2027-06-03 → 2027-06-16 (+13d). Complete tasks 0 → 17.

Changed:

| ID | Task | Start | Finish | Duration | Complete | Total float |
| --- | --- | --- | --- | --- | --- | --- |
| WDH-001.MIL | **Milestones** |  | 2027-06-03 → 2027-06-16 (+13d) |  |  |  |
| MIL-00010 | Notice to Proceed (NTP) | 2026-07-20 A | 2026-07-20 A |  | 0% → 100% | 0d → none |
| MIL-00060 | Long-Lead POs Issued | 2026-07-22 A | 2026-07-22 A |  | 0% → 100% | 27d → none |
| MIL-00070 | All Long-Lead Equipment On Site | 2026-12-15 → 2026-12-14 (-1d) | 2026-12-15 → 2026-12-14 (-1d) |  |  | 92d → 102d |
| MIL-00020 | Mechanical Completion | 2027-04-28 → 2027-05-11 (+13d) | 2027-04-28 → 2027-05-11 (+13d) |  |  |  |
| MIL-00030 | Substantial Completion | 2027-05-12 → 2027-05-25 (+13d) | 2027-05-12 → 2027-05-25 (+13d) |  |  |  |
| MIL-00040 | Ready for Service | 2027-05-19 → 2027-06-02 (+14d) | 2027-05-19 → 2027-06-02 (+14d) |  |  |  |
| CLS-00010 | Project Closeout | 2027-05-20 → 2027-06-03 (+14d) | 2027-06-03 → 2027-06-16 (+13d) |  |  |  |
| MIL-00050 | Final Completion | 2027-06-03 → 2027-06-16 (+13d) | 2027-06-03 → 2027-06-16 (+13d) |  |  |  |
| WDH-001.PRO | **Procurement** |  | 2026-12-15 → 2026-12-14 (-1d) |  |  |  |
| PRO-00010 | Issue PO — Structural Steel Joists & Deck | 2026-07-20 A | 2026-07-22 A |  | 0% → 100% | 27d → none |
| PRO-00040 | Issue PO — Dock Equipment | 2026-07-20 A | 2026-07-22 A |  | 0% → 100% | 27d → none |
| PRO-00070 | Issue PO — Main Electrical Switchgear | 2026-07-20 A | 2026-07-22 A |  | 0% → 100% | 27d → none |
| PRO-00020 | Fabricate & Deliver Structural Steel Joists & Deck | 2026-07-23 A | 2026-11-06 A |  | 0% → 100% | 27d → none |
| PRO-00050 | Fabricate & Deliver Dock Equipment | 2026-07-23 A | 2026-10-16 A |  | 0% → 100% | 122d → none |
| PRO-00080 | Fabricate & Deliver Main Electrical Switchgear | 2026-07-23 A | 2026-12-15 → 2026-12-14 (-1d) | 100d → 99d | 0% → 90% | 87d → 97d |
| PRO-00060 | Dock Equipment On Site | 2026-10-16 A | 2026-10-16 A |  | 0% → 100% | 122d → none |
| PRO-00030 | Structural Steel Joists & Deck On Site | 2026-11-06 A | 2026-11-06 A |  | 0% → 100% | 27d → none |
| PRO-00090 | Main Electrical Switchgear On Site | 2026-12-15 → 2026-12-14 (-1d) | 2026-12-15 → 2026-12-14 (-1d) |  |  | 87d → 97d |
| WDH-001.CON | **Construction** |  | 2027-04-28 → 2027-05-11 (+13d) |  |  |  |
| CON-00010 | Perform Mass Grading & Building Pad | 2026-07-20 A | 2026-08-21 A |  | 0% → 100% | 0d → none |
| CON-00020 | Install Site Utilities — Storm & Sanitary | 2026-08-03 A | 2026-08-28 A |  | 0% → 100% | 140d → none |
| CON-00030 | Install Site Utilities — Water & Fire Loop | 2026-08-03 A | 2026-08-21 A |  | 0% → 100% | 145d → none |
| WDH-001.CON.02 | **Concrete & Tilt-Wall** |  | 2026-11-25 → 2026-12-09 (+14d) |  |  |  |
| CON-00040 | Excavate & Form Spread Footings | 2026-08-24 A | 2026-09-14 A |  | 0% → 100% | 0d → none |
| CON-00050 | Place Concrete Spread Footings | 2026-09-15 A | 2026-09-28 A |  | 0% → 100% | 0d → none |
| CON-00060 | Pour Warehouse Floor Slab — Sections 1 & 2 (Casting Bed) | 2026-09-29 A | 2026-10-13 A |  | 0% → 100% | 0d → none |
| CON-00070 | Pour Warehouse Floor Slab — Sections 3 & 4 | 2026-10-14 A | 2026-10-27 A |  | 0% → 100% | 70d → none |
| CON-00080 | Cast Tilt-Wall Panels (64 Panels) | 2026-10-14 A | 2026-11-10 A |  | 0% → 100% | 0d → none |
| CON-00090 | Cure Tilt-Wall Panels | 2026-11-12 → 2026-11-24 A (+12d) | 2026-11-25 → 2026-12-09 (+14d) | 10d → 11d | 0% → 35% |  |
| WDH-001.CON.03 | **Structure & Envelope** | 2026-11-27 → 2026-12-10 (+13d) | 2027-02-09 → 2027-02-23 (+14d) |  |  |  |
| CON-00100 | Erect Tilt-Wall Panels with Mobile Crane | 2026-11-27 → 2026-12-10 (+13d) | 2026-12-17 → 2026-12-31 (+14d) |  |  |  |
| CON-00110 | Erect Structural Steel Joists & Roof Deck | 2026-12-18 → 2027-01-04 (+17d) | 2027-01-11 → 2027-01-25 (+14d) |  |  |  |
| CON-00120 | Install TPO Roofing & Insulation | 2027-01-12 → 2027-01-26 (+14d) | 2027-02-09 → 2027-02-23 (+14d) |  |  |  |
| WDH-001.CON.04 | **Warehouse Interior** | 2027-02-10 → 2027-02-24 (+14d) | 2027-03-24 → 2027-04-06 (+13d) |  |  |  |
| CON-00130 | Install ESFR Fire Sprinkler System | 2027-02-10 → 2027-02-24 (+14d) | 2027-03-17 → 2027-03-30 (+13d) |  |  |  |
| CON-00140 | Install Warehouse Electrical & Lighting | 2027-02-10 → 2027-02-24 (+14d) | 2027-03-17 → 2027-03-30 (+13d) |  |  |  |
| CON-00160 | Install Dock Equipment & Overhead Doors | 2027-02-10 → 2027-02-24 (+14d) | 2027-02-24 → 2027-03-09 (+13d) |  |  |  |
| CON-00150 | Set & Energize Main Electrical Switchgear | 2027-03-18 → 2027-03-31 (+13d) | 2027-03-24 → 2027-04-06 (+13d) |  |  |  |
| WDH-001.CON.05 | **Office Buildout** | 2027-02-10 → 2027-02-24 (+14d) | 2027-04-28 → 2027-05-11 (+13d) |  |  |  |
| CON-00170 | Frame Metal Stud Walls — Office | 2027-02-10 → 2027-02-24 (+14d) | 2027-02-24 → 2027-03-09 (+13d) |  |  |  |
| CON-00180 | Rough-In MEP — Office | 2027-02-25 → 2027-03-10 (+13d) | 2027-03-17 → 2027-03-30 (+13d) |  |  |  |
| CON-00190 | Install Drywall, Ceilings & Insulation — Office | 2027-03-18 → 2027-03-31 (+13d) | 2027-04-07 → 2027-04-20 (+13d) |  |  |  |
| CON-00200 | Install Finishes & Storefront Glazing — Office | 2027-04-08 → 2027-04-21 (+13d) | 2027-04-28 → 2027-05-11 (+13d) |  |  |  |
| WDH-001.CON.06 | **Site Completion** | 2026-12-18 → 2027-01-04 (+17d) | 2027-01-26 → 2027-02-08 (+13d) |  |  |  |
| CON-00210 | Pave Car Court & Truck Court | 2026-12-18 → 2027-01-04 (+17d) | 2027-01-11 → 2027-01-25 (+14d) |  |  |  |
| CON-00220 | Install Landscaping & Irrigation | 2027-01-12 → 2027-01-26 (+14d) | 2027-01-26 → 2027-02-08 (+13d) |  |  |  |
| WDH-001.COM | **Commissioning & Closeout** | 2027-04-29 → 2027-05-12 (+13d) | 2027-05-19 → 2027-06-02 (+14d) |  |  |  |
| COM-00010 | Perform Commissioning & Start-Up | 2027-04-29 → 2027-05-12 (+13d) | 2027-05-12 → 2027-05-25 (+13d) |  |  |  |
| COM-00020 | Complete Punchlist & Final Inspections | 2027-04-29 → 2027-05-12 (+13d) | 2027-05-12 → 2027-05-25 (+13d) |  |  |  |
| COM-00030 | Execute Project Closeout | 2027-05-13 → 2027-05-26 (+13d) | 2027-05-19 → 2027-06-02 (+14d) |  |  |  |
